# 2016 winter shut down target hall schedule

Schedule from MS Project, 2016-02-11 to 2016-05-02, A marks actual dates.

## Calendars

- Standard: Mon-Fri 08:00-12:00, 13:00-17:00; Sat-Sun off.

## Resources

| Resource |
| --- |
| Wang.D |
| Cave.T |
| Fisher.C |
| McDonald.D |
| RPG |
| Jackson.D |
| Mjos.A |
| Minor.G |
| Paley.B |
| Vacuum Group |
| Plant Group |
| Target Group |

## Schedule

| ID | WBS | Task | Duration | Start | Finish | Predecessors | Complete | Remaining | Total slack | Free slack | Constraint | Resources | Work | Actual work |
| --- | --- | --- | --- | --- | --- | --- | --- | --- | --- | --- | --- | --- | --- | --- |
| 1 | 1 | **TM3 Service Chase and Containment box Field Check** | 2d | 2016-02-15 08:00 A | 2016-02-16 17:00 A |  | 100% |  |  |  |  |  | 48h | 48h |
| 2 | 1.1 | TM3 Service Chase and Containment box Field Check | 2d | 2016-02-15 08:00 A | 2016-02-16 17:00 A |  | 100% |  |  |  | start no earlier than 2016-02-15 08:00 | Target Group; RPG; Wang.D | 48h | 48h |
| 3 | 2 | **TARGET HALL WATER SYSTEM UPGRADE** | 5d | 2016-02-17 08:00 A | 2016-02-23 17:00 |  | 25% | 3.75d | 49d |  |  |  | 88h | 16h |
| 4 | 2.1 | Shielding Blocks Move for Work Area Accessing | 1d | 2016-02-17 08:00 A | 2016-02-17 17:00 A |  | 100% |  |  |  | finish no earlier than 2016-02-17 17:00 | Wang.D; McDonald.D | 16h | 16h |
| 5 | 2.2 | Water Sytem Upgrade and Test | 3d | 2016-02-19 08:00 | 2016-02-23 17:00 | 4 |  |  | 49d |  | start no earlier than 2016-02-19 08:00 | McDonald.D; Wang.D; Cave.T | 72h |  |
| 6 | 3 | **Shut Down Leak Check - Target Stations and Modules** | 4d | 2016-02-25 08:00 | 2016-03-01 17:00 |  |  |  | 11d |  |  |  | 64h |  |
| 7 | 3.1 | Module Disconnection-TM2/ITW | 1d | 2016-02-25 08:00 | 2016-02-25 17:00 | 4 |  |  | 46d | 0d | start no earlier than 2016-02-25 08:00 | Wang.D; McDonald.D | 16h |  |
| 8 | 3.2 | ITW and TM2 Vacuum Leak Check | 1d | 2016-02-26 08:00 | 2016-02-26 17:00 | 7 |  |  | 46d |  | start no earlier than 2016-01-28 08:00 | Wang.D; McDonald.D | 16h |  |
| 9 | 3.3 | Shielding Blocks Move- ITE to Storage Area | 0.5d | 2016-02-29 08:00 | 2016-02-29 12:00 |  |  |  | 9d | 0d | start no earlier than 2016-02-29 08:00 | Wang.D; McDonald.D | 8h |  |
| 10 | 3.4 | Module Disconnection-TM4-ITE | 0.5d | 2016-02-29 13:00 | 2016-02-29 17:00 | 9 |  |  | 9d | 0d | start no earlier than 2016-02-16 08:00 | Wang.D; McDonald.D | 8h |  |
| 11 | 3.5 | ITE and TM4 Vacuum leak Check | 1d | 2016-03-01 08:00 | 2016-03-01 17:00 | 10 |  |  | 9d | 0d | start no earlier than 2016-02-17 08:00 | McDonald.D; Wang.D | 16h |  |
| 12 | 4 | **ISAC Spent targets Shipment** | 6d | 2016-02-11 08:00 A | 2016-02-18 17:00 A |  | 100% |  |  |  |  |  | 40h | 40h |
| 13 | 4.1 | F308s Move- Ante Room to Target Hall | 0.5d | 2016-02-11 08:00 A | 2016-02-11 12:00 A |  | 100% |  |  |  | start no earlier than 2016-02-11 08:00 | Cave.T; Wang.D | 8h | 8h |
| 14 | 4.2 | Working area Set up | 0.5d | 2016-02-11 13:00 A | 2016-02-11 17:00 A | 13 | 100% |  |  |  | start no earlier than 2016-02-11 08:00 | Cave.T; Wang.D | 8h | 8h |
| 15 | 4.3 | Speant Targets Transfer- Mini Storage to F308s | 0.5d | 2016-02-18 08:00 A | 2016-02-18 12:00 A | 14 | 100% |  |  |  | start no earlier than 2016-02-18 08:00 | Cave.T; RPG; Wang.D | 12h | 12h |
| 16 | 4.4 | F308s Move- Target Hall to Ante Room | 0.5d | 2016-02-18 13:00 A | 2016-02-18 17:00 A | 15 | 100% |  |  |  | start no earlier than 2016-02-18 08:00 | Wang.D; McDonald.D; Cave.T | 12h | 12h |
| 17 | 5 | **TM2 with New Lp Ta Target to ITE** | 12d | 2016-03-02 08:00 | 2016-03-17 17:00 |  |  |  | 9d |  |  |  | 104h |  |
| 18 | 5.1 | New Lp Ta Target Insert into SHC | 0.25d | 2016-03-02 08:00 | 2016-03-02 10:00 | 11 |  |  | 9d | 0d | start no earlier than 2016-03-02 08:00 | Mjos.A; Fisher.C | 4h |  |
| 19 | 5.2 | Module Move -TM2- ITW to SHC | 0.25d | 2016-03-02 10:00 | 2016-03-02 12:00 | 18 |  |  | 9d | 0d | start no earlier than 2016-03-02 08:00 | Cave.T; Wang.D; McDonald.D | 6h |  |
| 20 | 5.3 | Target Removal and Electrical Check | 0.5d | 2016-03-02 13:00 | 2016-03-02 17:00 | 19 |  |  | 9d | 0d |  | Fisher.C; Cave.T; Wang.D | 12h |  |
| 21 | 5.4 | New Target Installation | 0.5d | 2016-03-03 08:00 | 2016-03-03 12:00 | 20 |  |  | 9d | 0d | start no earlier than 2016-03-03 08:00 | Fisher.C | 4h |  |
| 22 | 5.5 | TM2 with New Target Leak and Electrical Check- SHC | 0.5d | 2016-03-03 13:00 | 2016-03-03 17:00 | 21 |  |  | 9d | 0d | start no earlier than 2016-03-03 08:00 | Fisher.C; Cave.T; Wang.D | 12h |  |
| 23 | 5.6 | Module Move -TM2-SHC to TCS | 0.5d | 2016-03-04 08:00 | 2016-03-04 12:00 | 22 |  |  | 9d | 0d | start no earlier than 2016-03-04 08:00 | Wang.D; Cave.T | 8h |  |
| 24 | 5.7 | Module Connection- TM2 -TCS/Start of Pumps | 0.5d | 2016-03-04 13:00 | 2016-03-04 17:00 | 23 |  |  | 9d | 5d | start no earlier than 2016-03-04 08:00 | Wang.D | 4h |  |
| 25 | 5.8 | ITH MP1 Replacement | 1d | 2016-03-10 08:00 | 2016-03-10 17:00 |  |  |  | 37d |  | start no earlier than 2016-03-10 08:00 | Vacuum Group; Wang.D | 16h |  |
| 26 | 5.9 | Spent Target Move | 1d | 2016-03-14 08:00 | 2016-03-14 17:00 | 24 |  |  | 4d | 2d | start no earlier than 2016-03-14 08:00 | Cave.T; Fisher.C; Wang.D | 24h |  |
| 27 | 5.10 | Module Disconnection-TM2-TCS | 0.25d | 2016-03-17 08:00 | 2016-03-17 10:00 | 26 |  |  | 2d | 0d | start no earlier than 2016-03-17 08:00 | Wang.D | 2h |  |
| 28 | 5.11 | Module Move-TM2- TCS to ITE | 0.25d | 2016-03-17 10:00 | 2016-03-17 12:00 | 27 |  |  | 2d | 0d | start no earlier than 2016-03-17 08:00 | Wang.D; Cave.T | 4h |  |
| 29 | 5.12 | Module Connection-TM2-ITW/ Start of Pumps | 0.5d | 2016-03-17 13:00 | 2016-03-17 17:00 | 28 |  |  | 2d |  | start no earlier than 2016-03-11 08:00 | McDonald.D; Wang.D | 8h |  |

| ID | WBS | Task | Duration | Start | Finish | Predecessors | Total slack | Free slack | Constraint | Resources | Work |
| --- | --- | --- | --- | --- | --- | --- | --- | --- | --- | --- | --- |
| 30 | 6 | **TM4 with New UCx Target to ITE** | 4.7d | 2016-03-15 08:00 | 2016-03-21 14:36 |  | 30.3d |  |  |  | 77.6h |
| 31 | 6.1 | Module Move -TM4-ITE to SHC | 0.5d | 2016-03-15 08:00 | 2016-03-15 12:00 |  | 33.5d | 0d | start no earlier than 2016-03-15 08:00 | Cave.T; Wang.D | 8h |
| 32 | 6.2 | Target Removal and Electrical Check | 0.5d | 2016-03-15 13:00 | 2016-03-15 17:00 | 31 | 33.5d | 0d | start no earlier than 2016-03-08 08:00 | Wang.D; Cave.T | 8h |
| 33 | 6.3 | Module Move - TM4 -SHC to Silo | 0.5d | 2016-03-16 08:00 | 2016-03-16 12:00 | 32 | 33.5d |  | start no earlier than 2016-03-16 08:00 | Cave.T; Wang.D | 8h |
| 34 | 6.4 | Target Inspection | 1d | 2016-03-17 08:00 | 2016-03-17 17:00 |  | 32d |  | start no earlier than 2016-03-17 08:00 | Mjos.A; Fisher.C | 16h |
| 35 | 6.5 | Spent Target Move | 1d | 2016-03-18 08:00 | 2016-03-18 17:00 |  | 31d |  | start no earlier than 2016-03-18 08:00 | Fisher.C; Cave.T; Wang.D | 24h |
| 36 | 6.6 | New UCx Target Insert into SHC | 0.1d | 2016-03-21 08:00 | 2016-03-21 08:48 |  | 30.9d |  | start no earlier than 2016-03-21 08:00 | Mjos.A; Fisher.C | 1.6h |
| 37 | 6.7 | Module Move - TM4 - Silo to SHC | 0.2d | 2016-03-21 08:00 | 2016-03-21 09:36 |  | 30.8d |  | start no earlier than 2016-03-21 08:00 |  |  |
| 38 | 6.8 | New Target Installation | 0.1d | 2016-03-21 08:00 | 2016-03-21 08:48 |  | 30.3d | 0d | start no earlier than 2016-03-21 08:00 | Fisher.C | 0.8h |
| 39 | 6.9 | Leak Check and Electrical Check | 0.2d | 2016-03-21 08:48 | 2016-03-21 10:24 | 38 | 30.3d | 0d | start no earlier than 2016-03-18 08:00 | Fisher.C; Cave.T; Wang.D | 4.8h |
| 40 | 6.10 | Module Move -TM4-SHC to ITW | 0.2d | 2016-03-21 10:24 | 2016-03-21 12:00 | 39 | 30.3d | 0d | start no earlier than 2016-03-21 08:00 | Cave.T; Wang.D | 3.2h |
| 41 | 6.11 | Module Connection- TM4 -ITW/ Start of Pumps | 0.2d | 2016-03-21 13:00 | 2016-03-21 14:36 | 40 | 30.3d |  | start no earlier than 2016-03-09 08:00 | Wang.D; McDonald.D | 3.2h |
| 42 | 7 | TM3 Refurbishment | 30d | 2016-03-22 08:00 | 2016-05-02 17:00 | 29 | 0d |  | start no earlier than 2016-03-22 08:00 |  |  |
